# 5StoriesFinal

Schedule from MS Project, 2004-03-01 to 2005-07-19, costs in ريال.
Microsoft

## Calendars

- Persian: Mon-Wed 08:00-12:00, 13:00-17:00; Thu 08:00-12:00; Fri off; Sat-Sun 08:00-12:00, 13:00-17:00.

## Resources

| Resource | Group | Unit | Rate |
| --- | --- | --- | --- |
| کارگر حرفه ای | نیروی انسانی |  | 13500 |
| کارگر ساده | نیروی انسانی |  | 6500 |
| آب | مصالح | متر مکعب | 2500 |
| آجر | مصالح | عدد | 140 |
| بتن | مصالح | متر مکعب | 335000 |
| بلوک سفالی | مصالح | عدد | 1700 |
| پنجره | مصالح | کیلوگرم | 3120 |
| پوکه معدنی | مصالح | متر مکعب | 59100 |
| تجهیزات عایق کاری کف | لوازم |  | 2000 |
| چارچوب در و پنجره | مصالح | کیلو | 3120 |
| خاک | مصالح | تن | 35500 |
| داربست | لوازم |  | 500 |
| در | مصالح | متر مربع | 74100 |
| رابیتس | مصالح | متر مربع | 4960 |
| سیم برق | مصالح | متر | 2500 |
| سیمان | مصالح | تن | 239000 |
| رنگ | مصالح | کیلوگرم | 16200 |
| شن | مصالح | متر مکعب | 28600 |
| روشنایی | مصالح | عدد | 25000 |
| شیرآلات | مصالح | عدد | 89000 |
| شیشه | مصالح | متر مربع | 18300 |
| ضد زنگ | مصالح | لیتر | 7500 |
| کاشی | مصالح | متر مربع | 35900 |
| کانال کولر | مصالح | متر | 350000 |
| کابینت | مصالح | متر | 875000 |
| کلید و پریز | مصالح | سری | 14500 |
| گچ | مصالح | تن | 104500 |
| گونی | مصالح | متر مربع | 860 |
| لوازم آیفون | مصالح | عدد | 50000 |
| لوازم بهداشتی | مصالح | سری | 250000 |
| لوله چدنی | مصالح | متر | 15000 |
| لوله گالوانیزه | مصالح | متر | 7500 |
| ماسه | مصالح | متر مکعب | 47600 |
| موزاییک | مصالح | تن | 16300 |
| مواد آب بندی قالب | مصالح | کیلوگرم | 5000 |
| میلگرد | مصالح | کیلوگرم | 3030 |
| نبشی فولادی | مصالح | متر | 5000 |
| نرده و حفاظ | مصالح | متر | 12000 |
| (Cooler) وسایل سرمایشی | مصالح | عدد | 1200000 |
| (Package) وسایل گرمایشی | مصالح | عدد | 7000000 |
| بیل مکانیکی - با راننده | ماشین آلات | عدد | 150000 |
| پمپ بتن ریز - با راننده | ماشین آلات | عدد | 120000 |
| تراک میکسر - با راننده | ماشین آلات | عدد | 140000 |
| کامیون - با راننده | ماشین آلات | عدد | 100000 |
| تجهیرات نقشه برداری | لوازم |  | 50000 |
| قالب بتن ریزی | لوازم |  | 1000 |
| وسایل بنّایی - بیل و کلنگ و غیره | لوازم |  | 5000 |
| وسیله برش فلز | لوازم |  | 5000 |
| سنگ نما | مصالح | متر مربع | 88600 |
| ویبراتور | لوازم |  | 5000 |
| لوله خرطومی برق | مصالح | متر | 5000 |
| بتن مگر | مصالح | متر مکعب | 150000 |
| ورق فولادی | مصالح | متر مربع | 20000 |
| تیرچه | مصالح | متر | 25000 |
| جک قالب بندی | لوازم |  | 1000 |
| سرامیک | مصالح | متر مربع | 46500 |
| سنگ تزیینی | مصالح | متر مربع | 73500 |
| وسایل نقاشی | لوازم |  | 2000 |
| قیر | مصالح | کیلوگرم | 1070 |
| کمد دیواری | مصالح | متر مربع | 94500 |
| سنگ قرنیز | مصالح | متر | 4240 |
| استاد کار بتن | نیروی انسانی |  | 15000 |
| آرماتوربند | نیروی انسانی |  | 15000 |
| آهنگر | نیروی انسانی |  | 15000 |
| برقکار | نیروی انسانی |  | 15000 |
| سنگ کار | نیروی انسانی |  | 15000 |
| شیشه بر | نیروی انسانی |  | 15000 |
| عایقکار | نیروی انسانی |  | 15000 |
| قالب بند | نیروی انسانی |  | 15000 |
| کابینت ساز | نیروی انسانی |  | 15000 |
| کاشی کار | نیروی انسانی |  | 15000 |
| کانال ساز | نیروی انسانی |  | 15000 |
| آرماتوربند کمکی | نیروی انسانی |  | 7000 |
| آهنگر کمکی | نیروی انسانی |  | 7000 |
| برقکار کمکی | نیروی انسانی |  | 7000 |
| بنای بتن کمکی | نیروی انسانی |  | 7000 |
| سنگ کار کمکی | نیروی انسانی |  | 7000 |
| شیشه بر کمکی | نیروی انسانی |  | 7000 |
| عایقکار کمکی | نیروی انسانی |  | 7000 |
| قالب بند کمکی | نیروی انسانی |  | 7000 |
| کابینت ساز کمکی | نیروی انسانی |  | 7000 |
| کاشیکار کمکی | نیروی انسانی |  | 7000 |
| کانال ساز کمکی | نیروی انسانی |  | 7000 |
| گچکار کمکی | نیروی انسانی |  | 7000 |
| لوله کش کمکی | نیروی انسانی |  | 7000 |
| نجار کمکی | نیروی انسانی |  | 7000 |
| نقاش کمکی | نیروی انسانی |  | 7000 |
| گچکار | نیروی انسانی |  | 15000 |
| لوله کش | نیروی انسانی |  | 15000 |
| نجار | نیروی انسانی |  | 15000 |
| نقاش ساختمان | نیروی انسانی |  | 15000 |
| نقشه بردار | نیروی انسانی |  | 15000 |

## Schedule

| ID | WBS | Task | Duration | Start | Finish | Predecessors | Total slack | Free slack | Resources | Work | Cost |
| --- | --- | --- | --- | --- | --- | --- | --- | --- | --- | --- | --- |
| 1 | 1 | **اجرای ساختمان چهار طبقه با زیرزمین** | 398d | 2004-03-01 | 2005-07-19 |  | 0d |  |  | 335667h | 1,644,568,781.13 |
| 2 | 1.1 | تجهیز کارگاه | 10d | 2004-03-01 | 2004-03-13 |  | 0d |  | تجهیرات نقشه برداری [75%]; نرده و حفاظ [200 متر]; کارگر ساده [150%]; نقشه بردار [75%] | 240h | 7,080,000 |
| 3 | 1.2 | **اجرای پی** | 22.6d | 2004-03-10 | 2004-04-08 |  | 0d |  |  | 493.6h | 51,597,700 |
| 4 | 1.2.1 | گودبرداری وپی کنی | 3d | 2004-03-10 | 2004-03-14 | 2SS+7% | 0d |  | کارگر حرفه ای; بیل مکانیکی - با راننده [1 عدد]; کامیون - با راننده [2 عدد]; کارگر ساده | 105.6h | 7,200,000 |
| 5 | 1.2.2 | تسطیح و رگلاژ کف پی | 1d | 2004-03-15 | 2004-03-15 | 4SS+5% | 0d |  | کارگر ساده [240%]; کارگر حرفه ای [80%]; وسایل بنّایی - بیل و کلنگ و غیره [80%] | 32h | 243,200 |
| 6 | 1.2.3 | اجرای بتن مگر | 1d | 2004-03-16 | 2004-03-16 | 5 | 0d |  | بتن مگر [12 متر مکعب]; پمپ بتن ریز - با راننده [0.62 عدد]; تراک میکسر - با راننده [1 عدد]; استاد کار بتن; بنای بتن کمکی [200%] | 37h | 3,752,000 |
| 7 | 1.2.4 | آماده سازی و اجرای آرماتورهای پی | 4d | 2004-03-17 | 2004-03-22 | 6 | 0d |  | آرماتوربند کمکی [200%]; آرماتوربند; میلگرد [4000 کیلوگرم] | 95h | 13,041,000 |
| 8 | 1.2.5 | اجرای قالب بندی پی | 5d | 2004-03-20 | 2004-03-25 | 7SS+4% | 0d |  | قالب بند; قالب بند کمکی [200%]; مواد آب بندی قالب [10 کیلوگرم] | 80h | 930,000 |
| 9 | 1.2.6 | نصب و کنترل کف ستونها | 1d | 2004-03-25 | 2004-03-27 | 8 | 0d |  | کارگر ساده [200%]; کارگر حرفه ای; ورق فولادی [2 متر مربع] | 16h | 200,000 |
| 10 | 1.2.7 | اجرای بتن پی | 3d | 2004-03-27 | 2004-03-30 | 9 | 0d |  | استاد کار بتن; بنای بتن کمکی [200%]; تراک میکسر - با راننده [1 عدد]; پمپ بتن ریز - با راننده [1 عدد]; بتن [60 متر مکعب] | 112h | 25,996,000 |
| 11 | 1.2.8 | عمل آوری بتن پی | 7d | 2004-03-30 | 2004-04-08 | 10 | 0d |  | کارگر ساده [28.6%]; گونی [150 متر مربع]; آب [1 متر مکعب] | 16h | 235,500 |
| 12 | 1.3 | **اجرای اسکلت بتنی** | 137.9d | 2004-04-08 | 2004-09-30 |  | 0d |  | داربست [10000%]; جک قالب بندی [1000%]; قالب بتن ریزی [5000%]; وسیله برش فلز; ویبراتور [200%] | 183155h | 529,948,036.23 |
| 13 | 1.3.1 | **اجرای ستونهای زیرزمین** | 10.8d | 2004-04-08 | 2004-04-21 |  | 0d |  |  | 262h | 18,274,750 |
| 14 | 1.3.1.1 | آرماتوربندی 0 | 4d | 2004-04-08 | 2004-04-13 | 11 | 0d |  | میلگرد [1400 کیلوگرم]; آرماتوربند; آرماتوربند کمکی [114.3%] | 64h | 4,946,000 |
| 15 | 1.3.1.2 | قالب بندی 0 | 2d | 2004-04-11 | 2004-04-13 | 14SS+4.5% | 0d |  | مواد آب بندی قالب [10 کیلوگرم]; قالب بند; قالب بند کمکی [200%] | 32h | 402,000 |
| 16 | 1.3.1.3 | بتن ریزی و نگهداری 0 | 7d | 2004-04-13 | 2004-04-21 | 15 | 0d |  | بتن [7 متر مکعب]; پمپ بتن ریز - با راننده [1 عدد]; آب [0.5 متر مکعب]; تراک میکسر - با راننده [0.39 عدد]; گونی [75 متر مربع]; استاد کار بتن; کارگر ساده; بنای بتن کمکی [28.6%] | 166h | 12,926,750 |
| 17 | 1.3.2 | **اجرای سقف زیر زمین** | 15.6d | 2004-04-25 | 2004-05-15 |  | 0d |  |  | 416h | 60,257,500 |
| 18 | 1.3.2.1 | بازکردن قالبهای ستون 0 | 1d | 2004-04-25 | 2004-04-26 | 16FS+2d | 0d |  | قالب بند کمکی [200%] | 16h | 112,000 |
| 19 | 1.3.2.2 | آرماتوربندی تیرها 0 | 4d | 2004-04-26 | 2004-05-01 | 18SS+9% | 0d |  | میلگرد [5000 کیلوگرم]; آرماتوربند; آرماتوربند کمکی [87.5%] | 60h | 15,826,000 |
| 20 | 1.3.2.3 | قالب بندی تیرها 0 | 1d | 2004-05-01 | 2004-05-01 | 19SS+8% | 0d |  | مواد آب بندی قالب [12 کیلوگرم]; قالب بند; قالب بند کمکی [200%] | 24h | 292,000 |
| 21 | 1.3.2.4 | اجرای تیرچه ها و اتصالات آنها 0 | 2d | 2004-05-01 | 2004-05-02 | 20SS | 2.5d | 0d | تیرچه [600 متر]; کارگر حرفه ای; کارگر ساده [200%] | 48h | 15,424,000 |
| 22 | 1.3.2.5 | قرار دادن بلوکهای سقف 0 | 2d | 2004-05-03 | 2004-05-04 | 21 | 2.5d |  | بلوک سفالی [1700 عدد]; کارگر حرفه ای; کارگر ساده [200%] | 48h | 3,314,000 |
| 23 | 1.3.2.6 | آرماتوربندی سقف 0 | 1d | 2004-05-05 | 2004-05-05 | 20FS+3d | 0d |  | آرماتوربند کمکی [200%]; آرماتوربند; میلگرد [350 کیلوگرم] | 24h | 1,292,500 |
| 24 | 1.3.2.7 | نصب جکهای قالب بندی 0 | 2d | 2004-05-05 | 2004-05-08 | 23SS+5% | 0d |  | کارگر ساده [200%]; کارگر حرفه ای | 48h | 424,000 |
| 25 | 1.3.2.8 | بتن ریزی سقف و نگهداری 0 | 5d | 2004-05-09 | 2004-05-15 | 23, 22, 24 | 0d |  | آب [2 متر مکعب]; بتن [42 متر مکعب]; پمپ بتن ریز - با راننده [1 عدد]; تراک میکسر - با راننده [1 عدد]; گونی [300 متر مربع]; استاد کار بتن; بنای بتن کمکی [83.3%]; کارگر ساده | 148h | 23,573,000 |

| ID | WBS | Task | Duration | Start | Finish | Predecessors | Total slack | Free slack | Resources | Work | Cost |
| --- | --- | --- | --- | --- | --- | --- | --- | --- | --- | --- | --- |
| 26 | 1.3.3 | **اجرای ستونهای طبقه اول** | 17.7d | 2004-05-01 | 2004-05-23 |  | 0d |  |  | 250.13h | 15,941,132.98 |
| 27 | 1.3.3.1 | آرماتوربندی 1 | 6.8d | 2004-05-01 | 2004-05-10 | 19 | 5.64d | 0d | میلگرد [1400 کیلوگرم]; آرماتوربند; آرماتوربند کمکی [200%] | 64h | 4,946,000 |
| 28 | 1.3.3.2 | قالب بندی 1 | 2d | 2004-05-04 | 2004-05-08 | 27SS+4.5% | 5.64d |  | مواد آب بندی قالب [10 کیلوگرم]; قالب بند; قالب بند کمکی [200%] | 32h | 402,000 |
| 29 | 1.3.3.3 | بتن ریزی و نگهداری 1 | 7d | 2004-05-15 | 2004-05-23 | 28, 25 | 0d |  | بتن [7 متر مکعب]; پمپ بتن ریز - با راننده [0.7 عدد]; آب [0.5 متر مکعب]; تراک میکسر - با راننده [0.71 عدد]; گونی [75 متر مربع]; استاد کار بتن [70.2%]; بنای بتن کمکی [28.6%]; کارگر ساده | 154.13h | 10,593,132.98 |
| 30 | 1.3.4 | **اجرای سقف طبقه اول** | 23d | 2004-05-26 | 2004-06-23 |  | 0d |  |  | 400h | 60,081,500 |
| 31 | 1.3.4.1 | بازکردن قالبهای ستون 1 | 1d | 2004-05-26 | 2004-05-26 | 29FS+2d | 0d |  | قالب بند کمکی | 8h | 56,000 |
| 32 | 1.3.4.2 | آرماتوربندی تیرها 1 | 4d | 2004-05-26 | 2004-06-01 | 31SS+8% | 0d |  | میلگرد [5000 کیلوگرم]; آرماتوربند; آرماتوربند کمکی [87.5%] | 60h | 15,826,000 |
| 33 | 1.3.4.3 | قالب بندی تیرها 1 | 1d | 2004-05-31 | 2004-06-01 | 32SS+8% | 0d |  | مواد آب بندی قالب [12 کیلوگرم]; قالب بند; قالب بند کمکی [200%] | 24h | 292,000 |
| 34 | 1.3.4.4 | اجرای تیرچه ها و اتصالات آنها 1 | 2d | 2004-06-12 | 2004-06-13 | 33SS | 1.5d | 0d | تیرچه [600 متر]; کارگر حرفه ای; کارگر ساده [200%] | 48h | 15,424,000 |
| 35 | 1.3.4.5 | قرار دادن بلوکهای سقف 1 | 2d | 2004-06-14 | 2004-06-15 | 34 | 1.5d |  | بلوک سفالی [1700 عدد]; کارگر حرفه ای; کارگر ساده [200%] | 48h | 3,314,000 |
| 36 | 1.3.4.6 | آرماتوربندی سقف 1 | 1d | 2004-06-06 | 2004-06-06 | 33FS+3d | 0d |  | آرماتوربند کمکی [200%]; آرماتوربند; میلگرد [350 کیلوگرم] | 24h | 1,292,500 |
| 37 | 1.3.4.7 | نصب جکهای قالب بندی 1 | 2d | 2004-06-15 | 2004-06-17 | 36SS+5% | 0d |  | کارگر ساده [300%]; کارگر حرفه ای | 48h | 424,000 |
| 38 | 1.3.4.8 | بتن ریزی سقف و نگهداری 1 | 5d | 2004-06-19 | 2004-06-23 | 36, 35, 37 | 0d |  | آب [2 متر مکعب]; بتن [42 متر مکعب]; پمپ بتن ریز - با راننده [1 عدد]; تراک میکسر - با راننده [1 عدد]; گونی [300 متر مربع]; استاد کار بتن; بنای بتن کمکی [50%]; کارگر ساده | 140h | 23,453,000 |
| 39 | 1.3.5 | **اجرای ستونهای طبقه دوم** | 25.2d | 2004-06-01 | 2004-07-03 |  | 0d |  |  | 231.71h | 15,573,286.59 |
| 40 | 1.3.5.1 | آرماتوربندی 2 | 5d | 2004-06-01 | 2004-06-07 | 32 | 13.95d | 0d | میلگرد [1400 کیلوگرم]; آرماتوربند; آرماتوربند کمکی [200%] | 64h | 4,946,000 |
| 41 | 1.3.5.2 | قالب بندی 2 | 2d | 2004-06-05 | 2004-06-07 | 40SS+4.5% | 13.95d |  | مواد آب بندی قالب [10 کیلوگرم]; قالب بند; قالب بند کمکی [200%] | 32h | 402,000 |
| 42 | 1.3.5.3 | بتن ریزی و نگهداری 2 | 7d | 2004-06-24 | 2004-07-03 | 41, 38 | 0d |  | بتن [7 متر مکعب]; پمپ بتن ریز - با راننده [0.66 عدد]; آب [0.5 متر مکعب]; تراک میکسر - با راننده [0.71 عدد]; گونی [75 متر مربع]; استاد کار بتن [65.9%]; بنای بتن کمکی [28.6%]; کارگر ساده | 135.71h | 10,225,286.59 |
| 43 | 1.3.6 | **اجرای سقف طبقه دوم** | 17.5d | 2004-07-06 | 2004-07-27 |  | 0d |  |  | 424h | 60,441,500 |
| 44 | 1.3.6.1 | بازکردن قالبهای ستون 2 | 1d | 2004-07-06 | 2004-07-06 | 42FS+2d | 0d |  | قالب بند کمکی | 8h | 56,000 |
| 45 | 1.3.6.2 | آرماتوربندی تیرها 2 | 4d | 2004-07-06 | 2004-07-12 | 44SS+8% | 0d |  | میلگرد [5000 کیلوگرم]; آرماتوربند; آرماتوربند کمکی [87.5%] | 60h | 15,826,000 |
| 46 | 1.3.6.3 | قالب بندی تیرها 2 | 1d | 2004-07-11 | 2004-07-12 | 45SS+8% | 0d |  | مواد آب بندی قالب [12 کیلوگرم]; قالب بند; قالب بند کمکی [200%] | 24h | 292,000 |
| 47 | 1.3.6.4 | اجرای تیرچه ها و اتصالات آنها 2 | 2d | 2004-07-12 | 2004-07-14 | 46SS | 3.5d | 0d | تیرچه [600 متر]; کارگر حرفه ای; کارگر ساده [200%] | 48h | 15,424,000 |
| 48 | 1.3.6.5 | قرار دادن بلوکهای سقف 2 | 2d | 2004-07-14 | 2004-07-17 | 47 | 3.5d |  | بلوک سفالی [1700 عدد]; کارگر حرفه ای; کارگر ساده [200%] | 48h | 3,314,000 |
| 49 | 1.3.6.6 | آرماتوربندی سقف 2 | 1d | 2004-07-17 | 2004-07-17 | 46FS+3d | 0d |  | آرماتوربند کمکی [200%]; آرماتوربند; میلگرد [350 کیلوگرم] | 24h | 1,292,500 |
| 50 | 1.3.6.7 | نصب جکهای قالب بندی 2 | 4d | 2004-07-17 | 2004-07-21 | 49SS+5% | 0d |  | کارگر ساده; کارگر حرفه ای | 48h | 424,000 |
| 51 | 1.3.6.8 | بتن ریزی سقف و نگهداری 2 | 5d | 2004-07-21 | 2004-07-27 | 49, 48, 50 | 0d |  | آب [2 متر مکعب]; بتن [42 متر مکعب]; پمپ بتن ریز - با راننده [1 عدد]; تراک میکسر - با راننده [1 عدد]; گونی [300 متر مربع]; استاد کار بتن; بنای بتن کمکی [50%]; کارگر ساده | 164h | 23,813,000 |

| ID | WBS | Task | Duration | Start | Finish | Predecessors | Total slack | Free slack | Resources | Work | Cost |
| --- | --- | --- | --- | --- | --- | --- | --- | --- | --- | --- | --- |
| 52 | 1.3.7 | **اجرای ستونهای طبقه سوم** | 19.7d | 2004-07-12 | 2004-08-05 |  | 0d |  |  | 257.6h | 18,629,416.67 |
| 53 | 1.3.7.1 | آرماتوربندی 3 | 5d | 2004-07-12 | 2004-07-18 | 45 | 8.45d | 0d | میلگرد [1400 کیلوگرم]; آرماتوربند; آرماتوربند کمکی [200%] | 64h | 4,946,000 |
| 54 | 1.3.7.2 | قالب بندی 3 | 2d | 2004-07-14 | 2004-07-18 | 53SS+4.5% | 8.45d |  | مواد آب بندی قالب [10 کیلوگرم]; قالب بند; قالب بند کمکی [200%] | 32h | 402,000 |
| 55 | 1.3.7.3 | بتن ریزی و نگهداری 3 | 7d | 2004-07-28 | 2004-08-05 | 54, 51 | 0d |  | بتن [7 متر مکعب]; پمپ بتن ریز - با راننده [0.69 عدد]; آب [0.5 متر مکعب]; تراک میکسر - با راننده [0.71 عدد]; گونی [75 متر مربع]; استاد کار بتن [68.9%]; بنای بتن کمکی [28.6%]; کارگر ساده | 161.6h | 13,281,416.67 |
| 56 | 1.3.8 | **اجرای سقف طبقه سوم** | 16.5d | 2004-08-09 | 2004-08-29 |  | 0d |  |  | 416h | 62,001,500 |
| 57 | 1.3.8.1 | بازکردن قالبهای ستون 3 | 1d | 2004-08-09 | 2004-08-09 | 55FS+2d | 0d |  | قالب بند کمکی | 8h | 56,000 |
| 58 | 1.3.8.2 | آرماتوربندی تیرها 3 | 4d | 2004-08-09 | 2004-08-15 | 57SS+8% | 0d |  | میلگرد [5000 کیلوگرم]; آرماتوربند; آرماتوربند کمکی [87.5%] | 60h | 15,826,000 |
| 59 | 1.3.8.3 | قالب بندی تیرها 3 | 1d | 2004-08-14 | 2004-08-15 | 58SS+8% | 0d |  | مواد آب بندی قالب [12 کیلوگرم]; قالب بند; قالب بند کمکی [200%] | 24h | 292,000 |
| 60 | 1.3.8.4 | اجرای تیرچه ها و اتصالات آنها 3 | 2d | 2004-08-15 | 2004-08-17 | 59SS | 2.5d | 0d | تیرچه [600 متر]; کارگر حرفه ای; کارگر ساده [200%] | 48h | 15,424,000 |
| 61 | 1.3.8.5 | قرار دادن بلوکهای سقف 3 | 2d | 2004-08-17 | 2004-08-19 | 60 | 2.5d |  | بلوک سفالی [1700 عدد]; کارگر حرفه ای; کارگر ساده [200%] | 48h | 3,314,000 |
| 62 | 1.3.8.6 | آرماتوربندی سقف 3 | 1d | 2004-08-18 | 2004-08-19 | 59FS+3d | 0d |  | آرماتوربند کمکی [200%]; آرماتوربند; میلگرد [350 کیلوگرم] | 24h | 1,292,500 |
| 63 | 1.3.8.7 | نصب جکهای قالب بندی 3 | 3d | 2004-08-19 | 2004-08-23 | 62SS+5% | 0d |  | کارگر ساده [200%]; کارگر حرفه ای | 48h | 424,000 |
| 64 | 1.3.8.8 | بتن ریزی سقف و نگهداری 3 | 5d | 2004-08-23 | 2004-08-29 | 62, 61, 63 | 0d |  | آب [2 متر مکعب]; بتن [42 متر مکعب]; پمپ بتن ریز - با راننده [1 عدد]; تراک میکسر - با راننده [1 عدد]; گونی [300 متر مربع]; استاد کار بتن; بنای بتن کمکی [50%]; کارگر ساده [200%] | 156h | 25,373,000 |
| 65 | 1.3.9 | **اجرای ستونهای طبقه چهارم** | 18.7d | 2004-08-15 | 2004-09-07 |  | 0d |  |  | 259.84h | 18,845,950 |
| 66 | 1.3.9.1 | آرماتوربندی 4 | 5.5d | 2004-08-15 | 2004-08-22 | 58 | 7.22d | 0d | میلگرد [1400 کیلوگرم]; آرماتوربند; آرماتوربند کمکی [200%] | 64h | 4,946,000 |
| 67 | 1.3.9.2 | قالب بندی 4 | 2d | 2004-08-17 | 2004-08-21 | 66SS+4.5% | 7.22d |  | مواد آب بندی قالب [10 کیلوگرم]; قالب بند; قالب بند کمکی [200%] | 32h | 402,000 |
| 68 | 1.3.9.3 | بتن ریزی و نگهداری 4 | 7d | 2004-08-30 | 2004-09-07 | 67, 64 | 0d |  | بتن [7 متر مکعب]; پمپ بتن ریز - با راننده [0.72 عدد]; آب [0.5 متر مکعب]; تراک میکسر - با راننده [0.71 عدد]; گونی [75 متر مربع]; استاد کار بتن [72%]; بنای بتن کمکی [28.6%]; کارگر ساده | 163.84h | 13,497,950 |
| 69 | 1.3.10 | **اجرای سقف طبقه چهارم** | 16.5d | 2004-09-11 | 2004-09-30 |  | 0d |  |  | 416h | 62,001,500 |
| 70 | 1.3.10.1 | بازکردن قالبهای ستون 4 | 1d | 2004-09-11 | 2004-09-11 | 68FS+2d | 0d |  | قالب بند کمکی | 8h | 56,000 |
| 71 | 1.3.10.2 | آرماتوربندی تیرها 4 | 4d | 2004-09-11 | 2004-09-15 | 70SS+8% | 0d |  | میلگرد [5000 کیلوگرم]; آرماتوربند; آرماتوربند کمکی [87.5%] | 60h | 15,826,000 |
| 72 | 1.3.10.3 | قالب بندی تیرها 4 | 1d | 2004-09-15 | 2004-09-15 | 71SS+8% | 0d |  | مواد آب بندی قالب [12 کیلوگرم]; قالب بند; قالب بند کمکی [200%] | 24h | 292,000 |
| 73 | 1.3.10.4 | اجرای تیرچه ها و اتصالات آنها 4 | 2d | 2004-09-16 | 2004-09-19 | 72SS | 2.5d | 0d | تیرچه [600 متر]; کارگر حرفه ای; کارگر ساده [200%] | 48h | 15,424,000 |
| 74 | 1.3.10.5 | قرار دادن بلوکهای سقف 4 | 2d | 2004-09-19 | 2004-09-21 | 73 | 2.5d |  | بلوک سفالی [1700 عدد]; کارگر حرفه ای; کارگر ساده [200%] | 48h | 3,314,000 |
| 75 | 1.3.10.6 | آرماتوربندی سقف 4 | 1d | 2004-09-20 | 2004-09-21 | 72FS+3d | 0d |  | آرماتوربند کمکی [200%]; آرماتوربند; میلگرد [350 کیلوگرم] | 24h | 1,292,500 |
| 76 | 1.3.10.7 | نصب جکهای قالب بندی 4 | 2d | 2004-09-22 | 2004-09-25 | 75SS+5% | 0d |  | کارگر ساده [200%]; کارگر حرفه ای | 48h | 424,000 |
| 77 | 1.3.10.8 | بتن ریزی سقف و نگهداری 4 | 5d | 2004-09-25 | 2004-09-30 | 75, 74, 76 | 0d |  | آب [2 متر مکعب]; بتن [42 متر مکعب]; پمپ بتن ریز - با راننده [1 عدد]; تراک میکسر - با راننده [1 عدد]; گونی [300 متر مربع]; استاد کار بتن; بنای بتن کمکی [50%]; کارگر ساده | 156h | 25,373,000 |

| ID | WBS | Task | Duration | Start | Finish | Predecessors | Total slack | Free slack | Resources | Work | Cost |
| --- | --- | --- | --- | --- | --- | --- | --- | --- | --- | --- | --- |
| 78 | 1.4 | **اجرای بام** | 129d | 2005-01-15 | 2005-06-27 |  | 1.5d |  |  | 812h | 33,359,780 |
| 79 | 1.4.1 | اجرای جان پناه | 6d | 2005-01-15 | 2005-01-22 | 77FS+5d | 1.5d | 0d | سیمان [1.6 تن]; ماسه [5.6 متر مکعب]; آب [1 متر مکعب]; آجر [8680 عدد]; کارگر حرفه ای; کارگر ساده [300%] | 148h | 3,164,660 |
| 80 | 1.4.2 | نصب لوله ها برق | 4d | 2005-01-22 | 2005-01-26 | 79, 127 | 1.5d | 0d | برقکار; برقکار کمکی; کارگر ساده | 96h | 912,000 |
| 81 | 1.4.3 | کرم بندی وشیب بندی | 5d | 2005-01-26 | 2005-02-01 | 80 | 1.5d | 1d | کارگر حرفه ای; کارگر ساده [200%]; پوکه معدنی [32 متر مکعب] | 120h | 2,951,200 |
| 82 | 1.4.4 | اجرای سیمانکاری و بتن سبک | 10d | 2005-03-12 | 2005-03-23 | 81 | 0.5d | 0d | ماسه [4.2 متر مکعب]; سیمان [0.9 تن]; کارگر حرفه ای; کارگر ساده | 160h | 2,015,020 |
| 83 | 1.4.5 | عایق بندی | 5d | 2005-03-23 | 2005-03-29 | 82 | 0.5d | 0d | عایقکار کمکی [200%]; عایقکار; گونی [345 متر مربع]; قیر [910 کیلوگرم] | 120h | 2,430,400 |
| 84 | 1.4.6 | اجرای 1/5 سانتیمتر آسفالت | 5d | 2005-06-18 | 2005-06-22 | 83 | 18d | 0d | کارگر حرفه ای; کارگر ساده [200%]; ماسه [2.5 متر مکعب]; قیر [800 کیلوگرم]; شن [2.5 متر مکعب] | 120h | 2,106,500 |
| 85 | 1.4.7 | نصب و جادهی کولرها | 3d | 2005-06-23 | 2005-06-27 | 84 | 18d |  | نبشی فولادی [20 متر]; کارگر حرفه ای; کارگر ساده; (Cooler) وسایل سرمایشی [16 عدد] | 48h | 19,780,000 |
| 86 | 1.5 | **اجرای سقف نورگیر** | 17d | 2005-06-28 | 2005-07-19 |  | 0.5d |  |  | 236h | 2,507,910 |
| 87 | 1.5.1 | زیر سازی با پروفیل و قوطی | 6d | 2005-06-28 | 2005-07-05 | 83 | 0.5d | 0d | سیمان [0.05 تن]; ماسه [0.1 متر مکعب]; کارگر حرفه ای; کارگر ساده; آب [0.08 متر مکعب] | 96h | 976,910 |
| 88 | 1.5.2 | نصب پوشش شیشه | 4d | 2005-07-06 | 2005-07-11 | 87 | 0.5d | 0d | کارگر ساده; شیشه بر [37.5%]; شیشه [10 متر مربع] | 44h | 571,000 |
| 89 | 1.5.3 | اجرای درپوش دست انداز | 6d | 2005-07-12 | 2005-07-19 | 88 | 0.5d |  | کارگر حرفه ای; کارگر ساده | 96h | 960,000 |
| 90 | 1.6 | **اجرای تیغه بندی داخلی و خارجی** | 123.5d | 2004-05-22 | 2004-10-25 |  | 0d |  |  | 1680h | 61,268,124.8 |
| 91 | 1.6.1 | اجرای تیغه بندی داخلی و خارجی زیر زمین | 15d | 2004-05-22 | 2004-06-08 | 25FS+5d | 4.75d | 0d | آب [2 متر مکعب]; بلوک سفالی [5000 عدد]; سیمان [2.5 تن]; ماسه [12 متر مکعب]; کارگر حرفه ای [73.7%]; کارگر ساده [221.1%]; وسایل بنّایی - بیل و کلنگ و غیره [73.7%] | 336h | 12,302,752.63 |
| 92 | 1.6.2 | اجرای تیغه بندی داخلی و خارجی طبقه اول | 16d | 2004-06-30 | 2004-07-20 | 38FS+5d, 91 | 12.5d | 0d | آب [2 متر مکعب]; بلوک سفالی [5000 عدد]; سیمان [2.5 تن]; ماسه [12 متر مکعب]; کارگر حرفه ای [144.8%]; کارگر ساده [217.2%]; وسایل بنّایی - بیل و کلنگ و غیره [72.4%] | 336h | 12,286,389.66 |
| 93 | 1.6.3 | اجرای تیغه بندی داخلی و خارجی طبقه دوم | 24d | 2004-08-03 | 2004-09-02 | 51FS+5d, 92 | 2d | 0d | آب [2 متر مکعب]; بلوک سفالی [5000 عدد]; سیمان [2.5 تن]; ماسه [12 متر مکعب]; کارگر حرفه ای [63.6%]; کارگر ساده [127.3%]; وسایل بنّایی - بیل و کلنگ و غیره [63.6%] | 336h | 12,173,336.36 |
| 94 | 1.6.4 | اجرای تیغه بندی داخلی و خارجی طبقه سوم | 23d | 2004-09-07 | 2004-10-06 | 64FS+5d, 93 | 0.5d | 0d | آب [2 متر مکعب]; بلوک سفالی [5000 عدد]; سیمان [2.5 تن]; ماسه [12 متر مکعب]; کارگر حرفه ای [64.6%]; کارگر ساده [193.8%]; وسایل بنّایی - بیل و کلنگ و غیره [64.6%] | 336h | 12,185,946.15 |
| 95 | 1.6.5 | اجرای تیغه بندی داخلی و خارجی طبقه چهارم | 14d | 2004-10-07 | 2004-10-25 | 77FS+5d, 94 | 0d |  | آب [2 متر مکعب]; بلوک سفالی [5000 عدد]; سیمان [2.5 تن]; ماسه [12 متر مکعب]; کارگر حرفه ای [75%]; کارگر ساده [150%]; وسایل بنّایی - بیل و کلنگ و غیره [75%] | 336h | 12,319,700 |
| 96 | 1.7 | نصب چارچوب درها و پنجره ها و کمدها | 15d | 2005-05-11 | 2005-05-30 | 95SS | 0d |  | کارگر حرفه ای; کارگر ساده [200%]; چارچوب در و پنجره [1500 کیلو] | 360h | 7,860,000 |
| 97 | 1.8 | **اندود گچ و خاک سقف و دیوارها** | 130.5d | 2004-06-09 | 2004-11-22 |  | 4.75d |  |  | 2880h | 32,066,000 |
| 98 | 1.8.1 | اندود گچ و خاک سقف و دیوارهای زیر زمین | 18d | 2004-06-09 | 2004-07-01 | 91 | 4.75d | 0d | گچکار [80%]; گچکار کمکی [240%]; وسایل بنّایی - بیل و کلنگ و غیره [80%]; گچ [12 تن]; خاک [12 تن]; آب [4 متر مکعب] | 576h | 6,413,200 |
| 99 | 1.8.2 | اندود گچ و خاک سقف و دیوارهای طبقه اول | 18d | 2004-07-21 | 2004-08-12 | 92 | 126d | 0d | گچکار [80%]; گچکار کمکی [240%]; وسایل بنّایی - بیل و کلنگ و غیره [80%]; گچ [12 تن]; خاک [12 تن]; آب [4 متر مکعب] | 576h | 6,413,200 |
| 100 | 1.8.3 | اندود گچ و خاک سقف و دیوارهای طبقه دوم | 18d | 2004-09-08 | 2004-09-30 | 93 | 124d | 2d | گچکار [80%]; گچکار کمکی [240%]; وسایل بنّایی - بیل و کلنگ و غیره [80%]; گچ [12 تن]; خاک [12 تن]; آب [4 متر مکعب] | 576h | 6,413,200 |
| 101 | 1.8.4 | اندود گچ و خاک سقف و دیوارهای طبقه سوم | 18d | 2004-10-06 | 2004-10-30 | 94 | 83d | 0d | گچکار [80%]; گچکار کمکی [240%]; وسایل بنّایی - بیل و کلنگ و غیره [80%]; گچ [12 تن]; خاک [12 تن]; آب [4 متر مکعب] | 576h | 6,413,200 |
| 102 | 1.8.5 | اندود گچ و خاک سقف و دیوارهای طبقه چهارم | 18d | 2004-10-31 | 2004-11-22 | 95 | 71d | 0d | گچکار [80%]; گچکار کمکی [240%]; وسایل بنّایی - بیل و کلنگ و غیره [80%]; گچ [12 تن]; خاک [12 تن]; آب [4 متر مکعب] | 576h | 6,413,200 |

| ID | WBS | Task | Duration | Start | Finish | Predecessors | Total slack | Free slack | Constraint | Resources | Work | Cost |
| --- | --- | --- | --- | --- | --- | --- | --- | --- | --- | --- | --- | --- |
| 103 | 1.9 | **نماسازی** | 103d | 2005-03-08 | 2005-07-17 |  | 2d |  |  | داربست [15000%] | 125059h | 103,810,049.1 |
| 104 | 1.9.1 | نصب سنگ ازاره نما | 15d | 2005-03-08 | 2005-03-27 | 95, 79 | 2d | 0d |  | سنگ نما [300 متر مربع]; سیمان [0.5 تن]; ماسه [8 متر مکعب]; سنگ کار; سنگ کار کمکی [200%]; آب [1 متر مکعب] | 360h | 30,562,800 |
| 105 | 1.9.2 | اجرای نماها | 75d | 2005-03-28 | 2005-06-30 | 104 | 2d | 0d |  | سنگ کار; سنگ کار کمکی [200%]; ماسه [12 متر مکعب]; سیمان [2 تن]; آب [2 متر مکعب] | 1018.73h | 10,830,849.1 |
| 106 | 1.9.3 | بندکشی نما | 5d | 2005-07-03 | 2005-07-17 | 105 | 2d |  |  | کارگر ساده [200%]; ماسه [1 متر مکعب]; سیمان [0.2 تن]; آب [0.4 متر مکعب] | 80h | 616,400 |
| 107 | 1.10 | **اجرای تاسیسات مکانیکی - مرحله اول** | 198.5d | 2004-07-03 | 2005-03-12 |  | 4.75d |  |  |  | 2432h | 289,731,903.23 |
| 108 | 1.10.1 | **کنده کاری های مربوط به تاسیسات** | 115.5d | 2004-07-03 | 2004-11-25 |  | 4.75d |  |  |  | 240h | 1,932,903.23 |
| 109 | 1.10.1.1 | کنده کاری های مربوط به تاسیسات زیر زمین | 3d | 2004-07-03 | 2004-07-05 | 98 | 4.75d | 0d |  | کارگر حرفه ای [66.7%]; کارگر ساده [66.7%]; وسایل بنّایی - بیل و کلنگ و غیره [66.7%] | 48h | 400,000 |
| 110 | 1.10.1.2 | کنده کاری های مربوط به تاسیسات طبقه اول | 3d | 2004-09-30 | 2004-10-04 | 109SS, 99 | 124.5d | 2.5d |  | کارگر حرفه ای [66.7%]; کارگر ساده [66.7%]; وسایل بنّایی - بیل و کلنگ و غیره [66.7%] | 48h | 400,000 |
| 111 | 1.10.1.3 | کنده کاری های مربوط به تاسیسات طبقه دوم | 10d | 2004-10-04 | 2004-10-16 | 110SS, 100 | 122d | 20.5d | finish no earlier than 2004-10-16 | کارگر حرفه ای [38.7%]; کارگر ساده [87.1%]; وسایل بنّایی - بیل و کلنگ و غیره [38.7%] | 48h | 332,903.23 |
| 112 | 1.10.1.4 | کنده کاری های مربوط به تاسیسات طبقه سوم | 3d | 2004-11-07 | 2004-11-10 | 111SS, 101 | 83d | 12d |  | کارگر حرفه ای [66.7%]; کارگر ساده [66.7%]; وسایل بنّایی - بیل و کلنگ و غیره [66.7%] | 48h | 400,000 |
| 113 | 1.10.1.5 | کنده کاری های مربوط به تاسیسات طبقه چهارم | 3d | 2004-11-22 | 2004-11-25 | 112SS, 102 | 71d | 65.5d |  | کارگر حرفه ای [66.7%]; کارگر ساده [66.7%]; وسایل بنّایی - بیل و کلنگ و غیره [66.7%] | 48h | 400,000 |
| 114 | 1.10.2 | لوله کشی فاضلاب طبقات | 21d | 2004-07-03 | 2004-07-28 | 109SS | 4.75d | 0.25d |  | لوله کش; لوله کش کمکی [200%]; لوله چدنی [450 متر] | 504h | 11,622,000 |
| 115 | 1.10.3 | **لوله کشی آب سرد و گرم - سرمایشی و گرمایشی** | 108d | 2004-10-25 | 2005-03-12 |  | 66d |  |  |  | 1688h | 276,177,000 |
| 116 | 1.10.3.1 | لوله کشی طبقات | 21d | 2004-10-25 | 2004-11-21 | 114SS+8%, 95 | 81d | 0d |  | لوله کش کمکی [200%]; لوله کش; لوله گالوانیزه [425 متر] | 504h | 8,059,500 |
| 117 | 1.10.3.2 | لوله کشی شوفاژ | 25d | 2004-11-21 | 2004-12-22 | 116 | 81d | 0d |  | لوله کش; لوله کش کمکی; لوله گالوانیزه [225 متر] | 400h | 6,087,500 |
| 118 | 1.10.3.3 | تست لوله کشی | 4d | 2004-12-22 | 2004-12-27 | 117 | 81d | 0d |  | لوله کش; لوله کش کمکی | 64h | 704,000 |
| 119 | 1.10.3.4 | ضد زنگ لوله ها | 4d | 2004-12-28 | 2005-01-02 | 118 | 81d | 1.5d |  | کارگر ساده [200%]; ضد زنگ [200 لیتر] | 64h | 1,916,000 |
| 120 | 1.10.3.5 | عایقکاری لوله ها | 6d | 2005-02-05 | 2005-02-12 | 119 | 79.5d | 0.5d |  | عایقکار کمکی; عایقکار; قیر [200 کیلوگرم] | 96h | 1,270,000 |
| 121 | 1.10.3.6 | نصب پکیج | 5d | 2005-03-06 | 2005-03-12 | 120 | 102.5d |  |  | (Package) وسایل گرمایشی [16 عدد]; لوله کش; کارگر ساده [200%] | 80h | 112,860,000 |
| 122 | 1.10.3.7 | کانال کشی کولر طبقات | 30d | 2004-10-25 | 2004-12-01 | 95 | 66d | 19d |  | کانال ساز کمکی; کانال ساز; کانال کولر [400 متر] | 480h | 145,280,000 |
| 123 | 1.11 | **اجرای تاسیسات برقی - مرحله اول** | 88d | 2004-07-22 | 2004-11-10 |  | 5d |  |  |  | 1646h | 34,138,400 |
| 124 | 1.11.1 | ترسیم خط تراز | 3d | 2004-07-22 | 2004-07-26 | 114SS+7.5% | 5d | 0d |  | برقکار; کارگر ساده [200%] | 72h | 672,000 |
| 125 | 1.11.2 | شیارکنی دیوارها و طبقات | 16d | 2004-07-26 | 2004-08-15 | 124 | 5d | 0d |  | کارگر حرفه ای [73.3%]; کارگر ساده [146.7%]; وسایل بنّایی - بیل و کلنگ و غیره [73.3%] | 352h | 2,763,200 |
| 126 | 1.11.3 | نصب قوطی ها و جعبه های دسترسی طبقات | 17d | 2004-08-16 | 2004-09-06 | 125 | 5d | 0d |  | برقکار; برقکار کمکی | 272h | 2,992,000 |
| 127 | 1.11.4 | لوله کشی برق طبقات | 18d | 2004-08-19 | 2004-09-12 | 126SS+2% | 5d | 0d |  | لوله خرطومی برق [1300 متر]; برقکار; برقکار کمکی | 244h | 9,008,000 |
| 128 | 1.11.5 | پوشاندن روی لوله ها | 4d | 2004-10-25 | 2004-10-30 | 127 | 82.5d | 0d |  | کارگر حرفه ای; کارگر ساده; سیمان [0.2 تن]; ماسه [1.5 متر مکعب] | 64h | 759,200 |
| 129 | 1.11.6 | نصب تابلوهای برق | 10d | 2004-10-30 | 2004-11-10 | 128 | 82.5d | 77d |  | کارگر حرفه ای; برقکار | 160h | 2,280,000 |
| 130 | 1.11.7 | سیم کشی طبقات | 22d | 2004-08-24 | 2004-09-21 | 127SS+2% | 5d | 1.5d |  | برقکار [180%]; برقکار کمکی [200%]; سیم برق [4500 متر] | 482h | 15,664,000 |

| ID | WBS | Task | Duration | Start | Finish | Predecessors | Total slack | Free slack | Constraint | Resources | Work | Cost |
| --- | --- | --- | --- | --- | --- | --- | --- | --- | --- | --- | --- | --- |
| 131 | 1.12 | **کف سازی طبقات** | 191.5d | 2004-10-02 | 2005-06-01 |  | 5d |  |  |  | 7966.69h | 202,307,087.34 |
| 132 | 1.12.1 | پوکه ریزی | 18d | 2004-10-02 | 2004-10-24 | 130 | 5d | 0d |  | پوکه معدنی [100 متر مکعب]; کارگر ساده | 98h | 6,547,000 |
| 133 | 1.12.2 | اجرای سنگ موزاییک کف | 30d | 2004-10-12 | 2004-11-20 | 132SS+5% | 6d | 0d |  | آب [2 متر مکعب]; سیمان [4 تن]; ماسه [12 متر مکعب]; موزاییک [600 تن]; کاشی کار [200%]; کاشیکار کمکی [400%] | 1440h | 25,232,200 |
| 134 | 1.12.3 | **اجرای سرویسها و آشپزخانه ها** | 116.5d | 2005-01-04 | 2005-06-01 |  | 5d |  |  |  | 3756h | 114,049,130 |
| 135 | 1.12.3.1 | **کرم بندی** | 48d | 2005-01-04 | 2005-03-06 |  | 5d |  |  |  | 640h | 7,653,850 |
| 136 | 1.12.3.1.1 | کرم بندی زیر زمین | 5d | 2005-01-04 | 2005-01-10 | 132SS+2.5% | 5d | 0d |  | کارگر ساده [300%]; کارگر حرفه ای; ماسه [4.2 متر مکعب]; سیمان [0.9 تن]; آب [1.5 متر مکعب] | 160h | 1,738,770 |
| 137 | 1.12.3.1.2 | کرم بندی طبقه اول | 5d | 2005-02-02 | 2005-02-08 | 136 | 5d | 0d |  | کارگر ساده [200%]; کارگر حرفه ای; ماسه [4.2 متر مکعب]; سیمان [0.9 تن]; آب [1.5 متر مکعب] | 120h | 1,478,770 |
| 138 | 1.12.3.1.3 | کرم بندی طبقه دوم | 5d | 2005-02-15 | 2005-02-21 | 137 | 5d | 0d |  | کارگر ساده [200%]; کارگر حرفه ای; ماسه [4.2 متر مکعب]; سیمان [0.9 تن]; آب [1.5 متر مکعب] | 120h | 1,478,770 |
| 139 | 1.12.3.1.4 | کرم بندی طبقه سوم | 5d | 2005-02-22 | 2005-02-28 | 138 | 5d | 0d |  | کارگر ساده [200%]; کارگر حرفه ای; ماسه [4.2 متر مکعب]; سیمان [0.9 تن]; آب [1.5 متر مکعب] | 120h | 1,478,770 |
| 140 | 1.12.3.1.5 | کرم بندی طبقه چهارم | 5d | 2005-02-28 | 2005-03-06 | 139 | 5d | 0d |  | کارگر ساده [200%]; کارگر حرفه ای; ماسه [4.2 متر مکعب]; سیمان [0.9 تن]; آب [1.5 متر مکعب] | 120h | 1,478,770 |
| 141 | 1.12.3.2 | **عایقکاری** | 69.5d | 2005-01-11 | 2005-04-09 |  | 23d |  |  | تجهیزات عایق کاری کف | 1504h | 12,505,000 |
| 142 | 1.12.3.2.1 | عایقکاری زیر زمین | 8d | 2005-01-11 | 2005-01-20 | 136 | 48.5d | 43.5d |  | عایقکار; عایقکار کمکی [200%]; گونی [160 متر مربع]; قیر [300 کیلوگرم] | 192h | 2,314,600 |
| 143 | 1.12.3.2.2 | عایقکاری طبقه اول | 8d | 2005-02-13 | 2005-02-22 | 137 | 35d | 30d |  | عایقکار; عایقکار کمکی [200%]; قیر [300 کیلوگرم]; گونی [160 متر مربع] | 192h | 2,314,600 |
| 144 | 1.12.3.2.3 | عایقکاری طبقه دوم | 16d | 2005-03-02 | 2005-03-22 | 138 | 25d | 20d |  | عایقکار; عایقکار کمکی [200%]; قیر [300 کیلوگرم]; گونی [160 متر مربع] | 192h | 2,314,600 |
| 145 | 1.12.3.2.4 | عایقکاری طبقه سوم | 8d | 2005-03-30 | 2005-04-09 | 139 | 23d | 18d |  | عایقکار; عایقکار کمکی [200%]; قیر [300 کیلوگرم]; گونی [160 متر مربع] | 192h | 2,314,600 |
| 146 | 1.12.3.2.5 | عایقکاری طبقه چهارم | 8d | 2005-03-07 | 2005-03-16 | 140 | 5d | 0d |  | عایقکار; عایقکار کمکی [200%]; قیر [300 کیلوگرم]; گونی [160 متر مربع] | 180h | 2,134,600 |
| 147 | 1.12.3.3 | نصب سنگ توالت ها و کفشوهای طبقات | 9d | 2005-03-12 | 2005-03-22 | 146SS+5% | 5d | 0d |  | کارگر حرفه ای; کارگر ساده [138.9%]; لوازم بهداشتی [18 سری]; ماسه [0.8 متر مکعب]; سیمان [0.2 تن] | 172h | 6,207,880 |
| 148 | 1.12.3.4 | **اجرای کاشی و سرامیک** | 60d | 2005-03-17 | 2005-06-01 |  | 5d |  |  |  | 1440h | 87,682,400 |
| 149 | 1.12.3.4.1 | اجرای کاشی و سرامیک زیر زمین | 12d | 2005-03-17 | 2005-04-02 | 147SS+5%, 142 | 5d | 0d |  | آب [3 متر مکعب]; سرامیک [200 متر مربع]; سیمان [0.9 تن]; ماسه [3.8 متر مکعب]; کاشی کار [75%]; کاشیکار کمکی [150%]; کاشی [150 متر مربع]; وسایل بنّایی - بیل و کلنگ و غیره [75%] | 288h | 17,536,480 |
| 150 | 1.12.3.4.2 | اجرای کاشی و سرامیک طبقه اول | 12d | 2005-04-02 | 2005-04-17 | 149, 143 | 5d | 0d |  | آب [3 متر مکعب]; سرامیک [200 متر مربع]; سیمان [0.9 تن]; ماسه [3.8 متر مکعب]; کاشی کار [75%]; کاشیکار کمکی [150%]; کاشی [150 متر مربع]; وسایل بنّایی - بیل و کلنگ و غیره [75%] | 288h | 17,536,480 |
| 151 | 1.12.3.4.3 | اجرای کاشی و سرامیک طبقه دوم | 12d | 2005-04-17 | 2005-05-02 | 150, 144 | 5d | 0d |  | آب [3 متر مکعب]; سرامیک [200 متر مربع]; سیمان [0.9 تن]; ماسه [3.8 متر مکعب]; کاشی کار [75%]; کاشیکار کمکی [150%]; کاشی [150 متر مربع]; وسایل بنّایی - بیل و کلنگ و غیره [75%] | 288h | 17,536,480 |
| 152 | 1.12.3.4.4 | اجرای کاشی و سرامیک طبقه سوم | 12d | 2005-05-02 | 2005-05-17 | 151, 145 | 5d | 0d |  | آب [3 متر مکعب]; سرامیک [200 متر مربع]; سیمان [0.9 تن]; ماسه [3.8 متر مکعب]; کاشی کار [75%]; کاشیکار کمکی [150%]; کاشی [150 متر مربع]; وسایل بنّایی - بیل و کلنگ و غیره [75%] | 288h | 17,536,480 |
| 153 | 1.12.3.4.5 | اجرای کاشی و سرامیک طبقه چهارم | 12d | 2005-05-17 | 2005-06-01 | 152, 146, 120 | 5d |  |  | آب [3 متر مکعب]; سرامیک [200 متر مربع]; سیمان [0.9 تن]; ماسه [3.8 متر مکعب]; کاشی کار [75%]; کاشیکار کمکی [150%]; کاشی [150 متر مربع]; وسایل بنّایی - بیل و کلنگ و غیره [75%] | 288h | 17,536,480 |
| 154 | 1.12.4 | **اجرای قرنیزها و سنگ کف پنجره ها** | 35.5d | 2004-10-26 | 2004-12-09 |  | 97d |  |  |  | 392.69h | 9,959,307.34 |
| 155 | 1.12.4.1 | اجرای قرنیزها و سنگ کف پنجره های زیر زمین | 7d | 2004-10-26 | 2004-11-03 | 133SS+3.5% | 97d | 0d |  | آب [0.3 متر مکعب]; سیمان [0.3 تن]; ماسه [0.85 متر مکعب]; سنگ کار [65.1%]; سنگ کار کمکی [130.3%]; وسایل بنّایی - بیل و کلنگ و غیره [65.1%]; سنگ قرنیز [300 متر] | 104.69h | 2,229,394.62 |
| 156 | 1.12.4.2 | اجرای قرنیزها و سنگ کف پنجره های طبقه اول | 7.5d | 2004-11-03 | 2004-11-13 | 155 | 97d | 0d |  | آب [0.3 متر مکعب]; سیمان [0.3 تن]; ماسه [0.85 متر مکعب]; سنگ کار [23.4%]; سنگ کار کمکی [46.8%]; وسایل بنّایی - بیل و کلنگ و غیره [54.5%]; سنگ قرنیز [300 متر] | 72h | 1,928,182.73 |
| 157 | 1.12.4.3 | اجرای قرنیزها و سنگ کف پنجره های طبقه دوم | 7d | 2004-11-14 | 2004-11-22 | 156 | 97d | 0d |  | آب [0.3 متر مکعب]; سیمان [0.3 تن]; ماسه [0.85 متر مکعب]; سنگ کار [24.1%]; سنگ کار کمکی [48.2%]; وسایل بنّایی - بیل و کلنگ و غیره [56.2%]; سنگ قرنیز [300 متر] | 72h | 1,933,910 |
| 158 | 1.12.4.4 | اجرای قرنیزها و سنگ کف پنجره های طبقه سوم | 7d | 2004-11-22 | 2004-11-30 | 157 | 97d | 0d |  | آب [0.3 متر مکعب]; سیمان [0.3 تن]; ماسه [0.85 متر مکعب]; سنگ کار [24.1%]; سنگ کار کمکی [48.2%]; وسایل بنّایی - بیل و کلنگ و غیره [56.2%]; سنگ قرنیز [300 متر] | 72h | 1,933,910 |
| 159 | 1.12.4.5 | اجرای قرنیزها و سنگ کف پنجره های طبقه چهارم | 7d | 2004-12-01 | 2004-12-09 | 158 | 97d |  |  | آب [0.3 متر مکعب]; سیمان [0.3 تن]; ماسه [0.85 متر مکعب]; سنگ کار [24.1%]; سنگ کار کمکی [48.2%]; وسایل بنّایی - بیل و کلنگ و غیره [56.2%]; سنگ قرنیز [300 متر] | 72h | 1,933,910 |
| 160 | 1.12.5 | اجرای سقف کاذب | 24d | 2005-04-09 | 2005-05-08 | 159SS+5% | 0d |  | as late as possible | رابیتس [200 متر مربع]; کارگر حرفه ای; کارگر ساده [200%]; گچ [1 تن]; میلگرد [150 کیلوگرم] | 576h | 6,639,000 |

| ID | WBS | Task | Duration | Start | Finish | Predecessors | Total slack | Free slack | Resources | Work | Cost |
| --- | --- | --- | --- | --- | --- | --- | --- | --- | --- | --- | --- |
| 161 | 1.12.6 | **اجرای سنگ ازاره و سنگ پله و پاگرد** | 70d | 2004-11-20 | 2005-02-16 |  | 6d |  |  | 840h | 30,988,450 |
| 162 | 1.12.6.1 | اجرای سنگ ازاره و سنگ پله و پاگرد زیر زمین | 14d | 2004-11-20 | 2004-12-07 | 133 | 6d | 0d | سنگ تزیینی [62 متر مربع]; آب [0.5 متر مکعب]; سیمان [0.6 تن]; ماسه [3.9 متر مکعب]; سنگ کار [30%]; سنگ کار کمکی [60%]; وسایل بنّایی - بیل و کلنگ و غیره [60%] | 168h | 6,197,690 |
| 163 | 1.12.6.2 | اجرای سنگ ازاره و سنگ پله و پاگرد طبقه اول | 14d | 2004-12-07 | 2004-12-25 | 162 | 6d | 0d | سنگ تزیینی [62 متر مربع]; آب [0.5 متر مکعب]; سیمان [0.6 تن]; ماسه [3.9 متر مکعب]; سنگ کار [30%]; سنگ کار کمکی [60%]; وسایل بنّایی - بیل و کلنگ و غیره [60%] | 168h | 6,197,690 |
| 164 | 1.12.6.3 | اجرای سنگ ازاره و سنگ پله و پاگرد طبقه دوم | 14d | 2004-12-26 | 2005-01-11 | 163 | 6d | 0d | سنگ تزیینی [62 متر مربع]; آب [0.5 متر مکعب]; سیمان [0.6 تن]; ماسه [3.9 متر مکعب]; سنگ کار [30%]; سنگ کار کمکی [60%]; وسایل بنّایی - بیل و کلنگ و غیره [60%] | 168h | 6,197,690 |
| 165 | 1.12.6.4 | اجرای سنگ ازاره و سنگ پله و پاگرد طبقه سوم | 14d | 2005-01-12 | 2005-01-30 | 164 | 6d | 0d | سنگ تزیینی [62 متر مربع]; آب [0.5 متر مکعب]; سیمان [0.6 تن]; ماسه [3.9 متر مکعب]; سنگ کار [30%]; سنگ کار کمکی [60%]; وسایل بنّایی - بیل و کلنگ و غیره [60%] | 168h | 6,197,690 |
| 166 | 1.12.6.5 | اجرای سنگ ازاره و سنگ پله و پاگرد طبقه چهارم | 14d | 2005-01-30 | 2005-02-16 | 165 | 6d | 0d | سنگ تزیینی [62 متر مربع]; آب [0.5 متر مکعب]; سیمان [0.6 تن]; ماسه [3.9 متر مکعب]; سنگ کار [30%]; سنگ کار کمکی [60%]; وسایل بنّایی - بیل و کلنگ و غیره [60%] | 168h | 6,197,690 |
| 167 | 1.12.7 | نصب نرده راه پله و بالکونها | 36d | 2005-02-16 | 2005-04-03 | 166, 162, 163, 164, 165 | 63.5d |  | نرده و حفاظ [45 متر]; آهنگر; آهنگر کمکی [200%] | 864h | 8,892,000 |
| 168 | 1.13 | **سفیدکاری سقفها و دیوارها** | 101d | 2004-12-07 | 2005-04-14 |  | 24.5d |  |  | 3056h | 25,619,590.43 |
| 169 | 1.13.1 | سفیدکاری سقفها و دیوارهای زیر زمین | 20d | 2004-12-07 | 2005-01-02 | 109, 162 | 69.5d | 63.5d | گچکار کمکی [236.2%]; گچکار [78.7%]; وسایل بنّایی - بیل و کلنگ و غیره [78.7%]; آب [2 متر مکعب]; گچ [2.5 تن] | 592h | 4,863,696.81 |
| 170 | 1.13.2 | سفیدکاری سقفها و دیوارهای طبقه اول | 20d | 2005-01-03 | 2005-01-27 | 110, 163, 122 | 61d | 55d | گچکار کمکی [240%]; گچکار [80%]; وسایل بنّایی - بیل و کلنگ و غیره [80%]; آب [2 متر مکعب]; گچ [2.5 تن] | 640h | 5,514,250 |
| 171 | 1.13.3 | سفیدکاری سقفها و دیوارهای طبقه دوم | 20d | 2005-01-29 | 2005-02-22 | 111, 164, 122 | 53d | 47d | گچکار کمکی [240%]; گچکار [80%]; وسایل بنّایی - بیل و کلنگ و غیره [80%]; آب [2 متر مکعب]; گچ [2.5 تن] | 640h | 5,514,250 |
| 172 | 1.13.4 | سفیدکاری سقفها و دیوارهای طبقه سوم | 20d | 2005-03-21 | 2005-04-14 | 112, 165, 122 | 24.5d | 18.5d | گچکار کمکی [236.2%]; گچکار [78.7%]; وسایل بنّایی - بیل و کلنگ و غیره [78.7%]; آب [2 متر مکعب]; گچ [2.5 تن] | 592h | 4,863,696.81 |
| 173 | 1.13.5 | سفیدکاری سقفها و دیوارهای طبقه چهارم | 20d | 2005-02-23 | 2005-03-20 | 129, 113, 166, 122 | 6d | 0d | گچکار کمکی [236.2%]; گچکار [78.7%]; وسایل بنّایی - بیل و کلنگ و غیره [78.7%]; آب [2 متر مکعب]; گچ [2.5 تن] | 592h | 4,863,696.81 |
| 174 | 1.14 | نصب درهای چوبی | 15d | 2005-05-30 | 2005-06-18 | 173SS+20d, 96 | 0d |  | نجار; نجار کمکی [200%]; کمد دیواری [100 متر مربع]; در [350 متر مربع]; پنجره [1600 کیلوگرم] | 360h | 43,857,000 |
| 175 | 1.15 | نصب لوازم بهداشتی طبقات | 14d | 2005-03-23 | 2005-04-10 | 173SS+7.5% | 6d | 0d | لوله کش کمکی; لوله کش; لوازم بهداشتی [18 سری]; شیرآلات [80 عدد]; کارگر ساده [89.3%] | 324h | 14,734,000 |
| 176 | 1.16 | نصب کابینت های آشپزخانه طبقات | 17d | 2005-06-15 | 2005-07-06 | 175, 183 | 10d |  | کابینت ساز; کابینت ساز کمکی; کابینت [160 متر] | 272h | 142,992,000 |
| 177 | 1.17 | نصب شیشهای در و پنجره طبقات | 25d | 2005-06-19 | 2005-07-19 | 174 | 0d |  | شیشه بر کمکی [200%]; شیشه بر; شیشه [180 متر مربع] | 551h | 8,359,000 |
| 178 | 1.18 | **نقاشی سقف و دیوارها** | 66d | 2005-03-23 | 2005-06-15 |  | 0d |  | وسایل نقاشی [300%] | 3504h | 36,648,000 |
| 179 | 1.18.1 | نقاشی سقف و دیوارهای زیر زمین | 12d | 2005-03-23 | 2005-04-07 | 169, 175SS | 6d | 0d | نقاش ساختمان; نقاش کمکی [300%]; رنگ [200 کیلوگرم] | 384h | 6,696,000 |
| 180 | 1.18.2 | نقاشی سقف و دیوارهای طبقه اول | 12d | 2005-04-09 | 2005-04-23 | 179, 170 | 6d | 0d | نقاش ساختمان; نقاش کمکی [300%]; رنگ [200 کیلوگرم] | 384h | 6,696,000 |
| 181 | 1.18.3 | نقاشی سقف و دیوارهای طبقه دوم | 12d | 2005-04-24 | 2005-05-08 | 180, 171 | 6d | 0d | نقاش ساختمان; نقاش کمکی [300%]; رنگ [200 کیلوگرم] | 384h | 6,696,000 |
| 182 | 1.18.4 | نقاشی سقف و دیوارهای طبقه سوم | 12d | 2005-05-09 | 2005-05-23 | 181, 172 | 6d |  | نقاش ساختمان; نقاش کمکی [300%]; رنگ [200 کیلوگرم] | 384h | 6,696,000 |
| 183 | 1.18.5 | نقاشی سقف و دیوارهای طبقه چهارم | 12d | 2005-05-31 | 2005-06-15 | 182, 160FS+7.5%, 153SS+5%, 173, 167SS+5% | 0d |  | نقاش ساختمان; نقاش کمکی [300%]; رنگ [200 کیلوگرم] | 384h | 6,696,000 |
| 184 | 1.19 | **اجرای تاسیسات برقی - مرحله دوم** | 31d | 2005-06-04 | 2005-07-12 |  | 0d |  |  | 496h | 15,412,200 |
| 185 | 1.19.1 | نصب کلیدها و پریزهای طبقات | 12d | 2005-06-04 | 2005-06-18 | 183SS+2d | 0d |  | برقکار کمکی; برقکار; کلید و پریز [320 سری] | 192h | 6,752,000 |
| 186 | 1.19.2 | نصب روشنایی های دیواری و سقفی | 16d | 2005-06-19 | 2005-07-09 | 185 | 0d |  | رنگ [1 کیلوگرم]; روشنایی [180 عدد]; برقکار; برقکار کمکی | 256h | 7,332,200 |
| 187 | 1.19.3 | نصب و راه‌ اندازی آیفون طبقات | 3d | 2005-07-09 | 2005-07-12 | 186 | 0d |  | لوازم آیفون [16 عدد]; برقکار; برقکار کمکی | 48h | 1,328,000 |
| 188 | 1.20 | تمیز کاری و برچیدن کارگاه | 6d | 2005-07-12 | 2005-07-19 | 187 | 0d |  | کارگر حرفه ای; کارگر ساده [200%] | 144h | 1,272,000 |
